# Film

Schedule from MS Project, 2008-05-22 to 2010-02-01, scheduled back from the finish, costs in €.

## Calendars

- Standard: Mon-Fri 08:00-12:00, 13:00-17:00; Sat-Sun off. Exceptions (off unless hours are given): 2008-12-24 to 2008-12-26, 2009-12-24 to 2009-12-25.

## Resources

| Resource | Rate |
| --- | --- |
| Max E.T. Schmidt |  |
| Drehbuchautor |  |
| Vertragsanwälte | 500 |
| Versicherung | 750 |
| Regisseur |  |
| männliche Hauptrolle | 14000 |
| weibliche Hauptrolle | 8000 |
| männlicher Gegenspieler | 15000 |
| Bruder 2 | 7000 |
| Callgirl | 10000 |
| Obdachloser | 8000 |
| Statisten | 15 |
| Kameramann | 800 |
| Beleuchter | 700 |
| Tontechniker | 700 |
| Regieassistent | 700 |
| Maske | 200 |
| Kostüme | 300 |
| Hubschrauberpaket | 20000 |
| Stuntmen | 1200 |
| Autos | 4000 |
| Cutter | 400 |
| Komponisten |  |
| 3-D-Leute | 100 |
| Produktionsteam | 120 |
| Storyboardzeichner | 150 |
| Locationscout | 100 |

## Schedule

| ID | WBS | Task | Type | Duration | Start | Finish | Predecessors | Baseline start | Baseline finish | Baseline duration | Total slack | Free slack | Constraint | Resources | Work | Cost | Baseline cost |
| --- | --- | --- | --- | --- | --- | --- | --- | --- | --- | --- | --- | --- | --- | --- | --- | --- | --- |
| 1 | 1 | Idee | milestone | 0d | 2008-05-22 | 2008-05-22 |  | 2008-05-22 | 2008-05-22 | 0d | 0d |  |  | Max E.T. Schmidt |  |  |  |
| 2 | 2 | Idee schützen |  | 5d | 2008-05-22 | 2008-05-28 | 1 | 2008-05-22 | 2008-05-28 | 5d | 0d |  | as late as possible | Max E.T. Schmidt; Vertragsanwälte | 80h | 20,000 | 20,000 |
| 3 | 3 | Kontaktpersonen suchen |  | 2mo | 2008-05-29 | 2008-07-23 | 2 | 2008-05-29 | 2008-07-23 | 2mo | 0d |  | as late as possible | Max E.T. Schmidt | 320h |  |  |
| 4 | 4 | Verkauf der Idee an Produktionsfirma |  | 4w | 2008-07-24 | 2008-08-20 | 3 | 2008-07-24 | 2008-08-20 | 4w | 0d |  | as late as possible | Max E.T. Schmidt; Vertragsanwälte | 320h | 180,000 | 180,000 |
| 5 | 5 | **Drehbucherstellung** |  | 75d | 2008-08-21 | 2008-12-03 |  | 2008-08-21 | 2008-12-03 | 75d | 0d |  | as late as possible |  | 600h | 529,600 | 529,600 |
| 6 | 5.1 | Drehbuchautor aussuchen |  | 10d | 2008-08-21 | 2008-09-03 | 4 | 2008-08-21 | 2008-09-03 | 10d | 0d |  | as late as possible | Produktionsteam | 80h | 9,600 | 9,600 |
| 7 | 5.2 | Vertrag mit Drehbuchautor |  | 5d | 2008-09-04 | 2008-09-10 | 6 | 2008-09-04 | 2008-09-10 | 5d | 0d |  | as late as possible | Vertragsanwälte | 40h | 20,000 | 20,000 |
| 8 | 5.3 | Drehbuch schreiben |  | 3mo | 2008-09-11 | 2008-12-03 | 7 | 2008-09-11 | 2008-12-03 | 3mo | 0d |  | as late as possible | Drehbuchautor | 480h | 500,000 | 500,000 |
| 9 | 6 | Regisseur suchen |  | 10d | 2008-11-06 | 2008-11-19 | 4 | 2008-11-06 | 2008-11-19 | 10d | 55d | 0d | as late as possible | Produktionsteam | 80h | 1,009,600 | 1,009,600 |
| 10 | 7 | Teamplanung |  | 2w | 2008-11-20 | 2008-12-03 | 9 | 2008-11-20 | 2008-12-03 | 2w | 55d | 0d | as late as possible | Regisseur | 80h |  |  |
| 11 | 8 | Storyboard |  | 3mo | 2008-12-04 | 2009-03-02 | 8, 10 | 2008-12-04 | 2009-03-02 | 3mo | 0d |  | as late as possible | Storyboardzeichner | 480h | 72,000 | 72,000 |
| 12 | 9 | Locations festlegen |  | 2mo | 2009-01-13 | 2009-03-09 | 8, 10 | 2009-01-13 | 2009-03-09 | 2mo | 25d | 0d | as late as possible | Locationscout | 320h | 32,000 | 32,000 |
| 13 | 10 | **Schauspieler casting** |  | 20d | 2009-02-10 | 2009-03-09 |  | 2009-02-10 | 2009-03-09 | 20d | 0d |  | as late as possible |  | 484h | 43,200 | 43,200 |
| 14 | 10.1 | Hauptdarsteller |  | 2w | 2009-02-24 | 2009-03-09 | 8, 9 | 2009-02-24 | 2009-03-09 | 2w | 55d | 0d | as late as possible | Produktionsteam; Regisseur [50%] | 96h | 9,600 | 9,600 |
| 15 | 10.2 | Nebendarsteller |  | 4w | 2009-02-10 | 2009-03-09 | 8, 9 | 2009-02-10 | 2009-03-09 | 4w | 45d | 0d | as late as possible | Produktionsteam; Regisseur | 256h | 19,200 | 19,200 |
| 16 | 10.3 | Statisten |  | 10d | 2009-02-24 | 2009-03-09 | 9 | 2009-02-24 | 2009-03-09 | 10d | 120d | 0d | as late as possible | Produktionsteam | 80h | 9,600 | 9,600 |
| 17 | 10.4 | Stuntmen |  | 5d | 2009-03-03 | 2009-03-09 | 9, 11 | 2009-03-03 | 2009-03-09 | 5d | 0d |  | as late as possible | Produktionsteam; Regisseur [30%] | 52h | 4,800 | 4,800 |
| 18 | 11 | Besetzung abgeschlossen | milestone | 0d | 2009-03-10 | 2009-03-10 | 17, 14, 15, 16 | 2009-03-10 | 2009-03-10 | 0d | 0d |  | as late as possible |  |  |  |  |
| 19 | 12 | **Dreh** |  | 72d | 2009-03-10 | 2009-06-17 |  | 2009-03-10 | 2009-06-17 | 72d | 0d |  | as late as possible |  | 7260h | 32,005,460 | 32,005,460 |
| 20 | 12.1 | Innendrehs |  | 3mo | 2009-03-10 | 2009-06-01 | 18, 12 | 2009-03-10 | 2009-06-01 | 3mo | 0d |  | as late as possible | Beleuchter; Bruder 2; Kameramann; Callgirl; männliche Hauptrolle; männlicher Gegenspieler; Maske; Obdachloser; Regieassistent; Regisseur; Statisten [20%]; Tontechniker; Kostüme; weibliche Hauptrolle | 6336h | 31,393,440 | 31,393,440 |
| 21 | 12.2 | **Aussendrehs** |  | 12d | 2009-06-02 | 2009-06-17 |  | 2009-06-02 | 2009-06-17 | 12d | 0d |  | as late as possible |  | 924h | 612,020 | 612,020 |
| 22 | 12.2.1 | Hubschrauberaufnahmen |  | 3d | 2009-06-02 | 2009-06-04 | 12, 20 | 2009-06-02 | 2009-06-04 | 3d | 0d |  | as late as possible | Regisseur; Versicherung [12.5%]; männliche Hauptrolle [10%]; Hubschrauberpaket; Kameramann; Tontechniker; Regieassistent | 98.4h | 108,650 | 108,650 |
| 23 | 12.2.2 | Autoverfolgung |  | 4d | 2009-06-05 | 2009-06-10 | 17, 20, 22 | 2009-06-05 | 2009-06-10 | 4d | 0d |  | as late as possible | Versicherung [12.5%]; Regisseur; Regieassistent; Kameramann; Tontechniker; Beleuchter; Statisten [800%]; Autos [37.5%]; Bruder 2 [25%]; Callgirl [30%]; Stuntmen | 465.6h | 338,040 | 338,040 |
| 24 | 12.2.3 | Stunts |  | 3d | 2009-06-11 | 2009-06-15 | 17, 20, 23 | 2009-06-11 | 2009-06-15 | 3d | 0d |  | as late as possible | Stuntmen; Regisseur; Kameramann; Beleuchter; Tontechniker; Regieassistent; Maske; Kostüme; Versicherung [25%] | 192h | 114,900 | 114,900 |
| 25 | 12.2.4 | Schiffaufnahmen |  | 1d | 2009-06-16 | 2009-06-16 | 18, 12, 20, 24 | 2009-06-16 | 2009-06-16 | 1d | 0d |  | as late as possible | Regisseur; Kameramann; Beleuchter; Tontechniker; Statisten [800%]; Maske; Kostüme | 112h | 22,560 | 22,560 |
| 26 | 12.2.5 | Schiffsexplosion |  | 1d | 2009-06-17 | 2009-06-17 | 10, 20, 25 | 2009-06-17 | 2009-06-17 | 1d | 0d |  | as late as possible | Regisseur; Kameramann; Beleuchter; Tontechniker; Statisten; Regieassistent; 3-D-Leute; Versicherung [500%] | 56h | 27,870 | 27,870 |
| 27 | 13 | Dreh abgeschlossen | milestone | 0d | 2009-06-18 | 2009-06-18 | 20, 22, 23, 24, 25, 26 | 2009-06-18 | 2009-06-18 | 0d | 0d |  | as late as possible |  |  |  |  |

Notes:
- 9: Gesamtkosten für den Regisseur
- 10: Kameramann, Musikautor, Schnitttechnik, Stunts, Specialeffect-Team, Maske, Kostüme...

| ID | WBS | Task | Type | Duration | Start | Finish | Predecessors | Baseline start | Baseline finish | Baseline duration | Total slack | Free slack | Constraint | Resources | Work | Cost | Baseline cost |
| --- | --- | --- | --- | --- | --- | --- | --- | --- | --- | --- | --- | --- | --- | --- | --- | --- | --- |
| 28 | 14 | **Postproduction** |  | 60d | 2009-06-18 | 2009-09-09 |  | 2009-06-18 | 2009-09-09 | 60d | 0d |  | as late as possible |  | 2096h | 2,796,000 | 2,796,000 |
| 29 | 14.1 | Schnitt |  | 2mo | 2009-07-16 | 2009-09-09 | 27, 30, 31 | 2009-07-16 | 2009-09-09 | 2mo | 0d |  | as late as possible | Regisseur; Regieassistent; Cutter; Kameramann [50%] | 1120h | 480,000 | 480,000 |
| 30 | 14.2 | Tonaufnahmen |  | 1mo | 2009-06-18 | 2009-07-15 | 27 | 2009-06-18 | 2009-07-15 | 1mo | 0d |  | as late as possible | Regisseur [50%]; Regieassistent [50%]; Tontechniker; männliche Hauptrolle [10%]; weibliche Hauptrolle [10%]; Callgirl [10%]; Komponisten [80%] | 496h | 2,180,000 | 2,180,000 |
| 31 | 14.3 | Special Effects |  | 1mo | 2009-06-18 | 2009-07-15 | 27 | 2009-06-18 | 2009-07-15 | 1mo | 0d |  | as late as possible | 3-D-Leute; Regisseur [50%]; Cutter; Regieassistent [50%] | 480h | 136,000 | 136,000 |
| 32 | 15 | Film fertig | milestone | 0d | 2009-09-10 | 2009-09-10 | 29 | 2009-09-10 | 2009-09-10 | 0d | 0d |  | as late as possible |  |  |  |  |
| 33 | 16 | **Marketing** |  | 101d | 2009-09-10 | 2010-02-01 |  | 2009-09-10 | 2010-02-01 | 101d | 21d | 0d | as late as possible |  | 128h | 1,939,040 | 1,939,040 |
| 34 | 16.1 | Trailor |  | 4d | 2009-12-29 | 2010-01-01 | 32 | 2009-12-29 | 2010-01-01 | 4d | 76d | 0d | as late as possible | Regisseur; Produktionsteam; Cutter; Tontechniker | 128h | 39,040 | 39,040 |
| 35 | 16.2 | Merchandising Produkte |  | 2mo | 2009-12-01 | 2010-01-27 | 27 | 2009-12-01 | 2010-01-27 | 2mo | 118d | 0d | as late as possible |  |  | 250,000 | 250,000 |
| 36 | 16.3 | Buch zum Film |  | 3mo | 2009-11-05 | 2010-01-29 | 29 | 2009-11-05 | 2010-01-29 | 3mo | 40d | 0d | as late as possible |  |  | 100,000 | 100,000 |
| 37 | 16.4 | CD/DVD/Video |  | 3mo | 2009-11-06 | 2010-02-01 | 32 | 2009-11-06 | 2010-02-01 | 3mo | 41d | 0d | as late as possible |  |  | 250,000 | 250,000 |
| 38 | 16.5 | Pressetexte, Anzeigen, Plakate |  | 4mo | 2009-09-10 | 2010-01-01 | 32 | 2009-09-10 | 2010-01-01 | 4mo | 0d |  | as late as possible |  |  | 300,000 | 300,000 |
| 39 | 16.6 | Fernseh- und Printinterviews |  | 2mo | 2009-11-26 | 2010-01-22 | 32 | 2009-11-26 | 2010-01-22 | 2mo | 55d | 0d | as late as possible |  |  | 1,000,000 | 1,000,000 |
| 40 | 17 | Vorführung |  | 1d | 2010-02-01 | 2010-02-01 | 34FS+4w, 35FS+2d, 36, 37FF, 38FS+4w, 39FS+1w | 2010-02-01 | 2010-02-01 | 1d | 0d |  | as late as possible |  |  |  |  |
