# Handbuch

Schedule from MS Project, 2007-04-02 to 2007-06-08, costs in €.

## Calendars

- Standard: Mon-Fri 08:00-12:00, 13:00-17:00; Sat-Sun off. Exceptions (off unless hours are given): 2007-04-06, 2007-04-09, 2007-05-01, 2007-05-17, 2007-05-28, 2007-06-07.

## Resources

| Resource | Rate | Notes |
| --- | --- | --- |
| Projektleiter | 160 |  |
| Autor1 | 65 | Preise: / ·A: für Autorentätigkeit / ·B: für Messedienst / ·C: für Tests |
| Autor2 | 50 |  |
| externer Korrektor | 100 |  |
| Schulungsabteilung |  |  |
| PC | 50 |  |
| Druckerei |  |  |
| Azubi | 12 |  |

## Schedule

| ID | WBS | Task | Type | Duration | Start | Finish | Predecessors | Total slack | Free slack | Constraint | Resources | Work | Cost |
| --- | --- | --- | --- | --- | --- | --- | --- | --- | --- | --- | --- | --- | --- |
| 1 | 1 | **Jour Fixe** |  | 40.12d | 2007-04-02 11:00 | 2007-06-04 12:00 |  | 3.5d |  |  |  | 10h | 1,600 |
| 2 | 1.1 | Jour Fixe 1 |  | 1h | 2007-04-02 11:00 | 2007-04-02 12:00 |  | 43.5d |  | start no earlier than 2007-04-02 11:00 | Projektleiter | 1h | 160 |
| 3 | 1.2 | Jour Fixe 2 |  | 1h | 2007-04-10 11:00 | 2007-04-10 12:00 |  | 39.5d |  | start no earlier than 2007-04-10 11:00 | Projektleiter | 1h | 160 |
| 4 | 1.3 | Jour Fixe 3 |  | 1h | 2007-04-16 11:00 | 2007-04-16 12:00 |  | 35.5d |  | start no earlier than 2007-04-16 11:00 | Projektleiter | 1h | 160 |
| 5 | 1.4 | Jour Fixe 4 |  | 1h | 2007-04-23 11:00 | 2007-04-23 12:00 |  | 30.5d |  | start no earlier than 2007-04-23 11:00 | Projektleiter | 1h | 160 |
| 6 | 1.5 | Jour Fixe 5 |  | 1h | 2007-04-30 11:00 | 2007-04-30 12:00 |  | 25.5d |  | start no earlier than 2007-04-30 11:00 | Projektleiter | 1h | 160 |
| 7 | 1.6 | Jour Fixe 6 |  | 1h | 2007-05-07 11:00 | 2007-05-07 12:00 |  | 21.5d |  | start no earlier than 2007-05-07 11:00 | Projektleiter | 1h | 160 |
| 8 | 1.7 | Jour Fixe 7 |  | 1h | 2007-05-14 11:00 | 2007-05-14 12:00 |  | 16.5d |  | start no earlier than 2007-05-14 11:00 | Projektleiter | 1h | 160 |
| 9 | 1.8 | Jour Fixe 8 |  | 1h | 2007-05-21 11:00 | 2007-05-21 12:00 |  | 12.5d |  | start no earlier than 2007-05-21 11:00 | Projektleiter | 1h | 160 |
| 10 | 1.9 | Jour Fixe 9 |  | 1h | 2007-05-29 11:00 | 2007-05-29 12:00 |  | 7.5d |  | start no earlier than 2007-05-29 11:00 | Projektleiter | 1h | 160 |
| 11 | 1.10 | Jour Fixe 10 |  | 1h | 2007-06-04 11:00 | 2007-06-04 12:00 |  | 3.5d |  | start no earlier than 2007-06-04 11:00 | Projektleiter | 1h | 160 |
| 12 | 2 | **Vorbereitende Arbeiten** |  | 3.5d | 2007-04-02 08:00 | 2007-04-05 12:00 |  | 0.5d |  |  |  | 28h | 3,660 |
| 13 | 2.1 | Lieferung der Inhalte | milestone | 0d | 2007-04-02 08:00 | 2007-04-02 08:00 |  | 1.5d | 0d |  |  |  |  |
| 14 | 2.2 | Inhaltsverzeichnis erstellen |  | 2d | 2007-04-02 08:00 | 2007-04-03 17:00 | 13 | 1.5d | 1d |  | Projektleiter | 16h | 2,560 |
| 15 | 2.3 | Aufteilung in Kapitel |  | 0.5d | 2007-04-05 08:00 | 2007-04-05 12:00 | 14 | 0.5d | 0d | start no earlier than 2007-04-05 08:00 | Projektleiter; Autor1; Autor2 | 12h | 1,100 |
| 16 | 3 | **Verfassen der Unterlagen** |  | 29d | 2007-04-05 13:00 | 2007-05-22 12:00 |  | 0.5d |  |  |  | 456h | 31,036.7 |
| 17 | 3.1 | Unterlagen schreiben |  | 25d | 2007-04-05 13:00 | 2007-05-15 12:00 | 15 | 0.5d | 0d |  | Autor1; Autor2 | 400h | 23,456.3 |
| 18 | 3.2 | Unterlage inhaltlich prüfen |  | 5d | 2007-05-10 13:00 | 2007-05-18 12:00 | 17FS-3d | 0.5d | 0d |  | Projektleiter | 40h | 6,400 |
| 19 | 3.3 | Korrekturen einarbeiten |  | 2d | 2007-05-18 13:00 | 2007-05-22 12:00 | 18 | 0.5d | 0d |  | Autor1 | 16h | 1,180.4 |
| 20 | 3.4 | Betaversion | milestone | 0d | 2007-05-22 12:00 | 2007-05-22 12:00 | 19 | 0.5d | 0d |  |  |  |  |
| 21 | 4 | **Korrektur und Abschlussarbeiten** |  | 8d | 2007-05-22 13:00 | 2007-06-04 12:00 |  | 0d |  |  |  | 84h | 6,690.6 |
| 22 | 4.1 | Externe Korrektur |  | 3d | 2007-05-23 08:00 | 2007-05-25 17:00 | 20 | 0d |  | start no earlier than 2007-05-23 08:00 | externer Korrektor | 24h | 2,400 |
| 23 | 4.2 | Test-Schulungseinsatz |  | 3d | 2007-05-22 13:00 | 2007-05-25 12:00 | 20 | 0.5d |  |  | Schulungsabteilung; PC [50%] | 24h | 600 |
| 24 | 4.3 | Korrekturen einarbeiten |  | 2d | 2007-05-29 08:00 | 2007-05-30 17:00 | 22, 23 | 0d |  |  | Autor1 | 16h | 1,180.4 |
| 25 | 4.4 | Vorbereitung Druckunterlagen |  | 1d | 2007-05-31 08:00 | 2007-05-31 17:00 | 24 | 0d |  |  | Autor1 | 8h | 590.2 |
| 26 | 4.5 | Durchsicht der Druckfahnen |  | 1.5d | 2007-06-01 08:00 | 2007-06-04 12:00 | 25 | 0d |  |  | Projektleiter | 12h | 1,920 |
| 27 | 4.6 | Druckfreigabe | milestone | 0d | 2007-06-04 12:00 | 2007-06-04 12:00 | 26 | 0d |  |  | Projektleiter |  |  |
| 28 | 5 | Lieferung der gewünschten Unterlagen |  | 3d | 2007-06-04 13:00 | 2007-06-08 12:00 | 27 | 0d |  |  | Druckerei | 24h | 4,000 |
| 29 | 6 | Projektauswertung |  | 0.5d | 2007-06-08 13:00 | 2007-06-08 17:00 | 28 | 0d |  |  | Projektleiter; Azubi | 8h | 688 |

Notes:
- 17: Autoren vom 07.Mai - 11. Mai in Urlaub / Terminziel wird gehalten!!!
