# Messe

Schedule from MS Project, 2007-03-01 to 2007-03-19.

## Calendars

- Standard: Mon-Fri 08:00-12:00, 13:00-17:00; Sat-Sun off.
- Messekalender: Mon-Sun 08:00-18:00.

## Schedule

| ID | WBS | Task | Type | Duration | Start | Finish | Predecessors | Total slack | Free slack | Constraint | Calendar |
| --- | --- | --- | --- | --- | --- | --- | --- | --- | --- | --- | --- |
| 1 | 1 | Vorüberlegung |  | 4h | 2007-03-01 08:00 | 2007-03-01 12:00 |  | 4.5d | 0d |  |  |
| 2 | 2 | Planungteam zusammenstellen |  | 3h | 2007-03-01 13:00 | 2007-03-01 16:00 | 1 | 4.5d | 0d |  |  |
| 3 | 3 | Infoveranstaltung |  | 1d | 2007-03-01 16:00 | 2007-03-02 16:00 | 2 | 4.5d | 0d |  |  |
| 4 | 4 | **Vorbereitung der Veranstaltung** |  | 2.62d | 2007-03-02 16:00 | 2007-03-07 12:00 |  | 4.5d |  |  |  |
| 5 | 4.1 | **Catering** |  | 1.06d | 2007-03-02 16:00 | 2007-03-05 16:30 |  | 6.06d |  |  |  |
| 6 | 4.1.1 | Caterer anfragen |  | 4h | 2007-03-02 16:00 | 2007-03-05 11:00 | 3 | 6.06d | 0d |  |  |
| 7 | 4.1.2 | Speisen & Getränke bestellen |  | 0.5h | 2007-03-05 11:00 | 2007-03-05 11:30 | 6 | 6.06d | 0d |  |  |
| 8 | 4.1.3 | Servicepersonal aussuchen |  | 0.5d | 2007-03-05 11:30 | 2007-03-05 16:30 | 7 | 6.06d | 1.56d |  |  |
| 9 | 4.2 | **Messestand** |  | 2.62d | 2007-03-02 16:00 | 2007-03-07 12:00 |  | 4.5d |  |  |  |
| 10 | 4.2.1 | Standaufbau |  | 2d | 2007-03-02 16:00 | 2007-03-06 16:00 | 3 | 4.5d | 0d |  |  |
| 11 | 4.2.2 | Stand einrichten |  | 4h | 2007-03-06 16:00 | 2007-03-07 11:00 | 10 | 4.5d | 0d |  |  |
| 12 | 4.2.3 | Briefieng des Servicepersonals |  | 1h | 2007-03-07 11:00 | 2007-03-07 12:00 | 11 | 4.5d | 0d |  |  |
| 13 | 5 | Vorbereitung abgeschlossen | milestone | 0d | 2007-03-07 12:00 | 2007-03-07 12:00 | 8, 12 | 4.5d | 2.5d |  |  |
| 14 | 6 | Durchführung |  | 50h | 2007-03-12 08:00 | 2007-03-16 18:00 | 13 | 2.5d | 0d | start no earlier than 2007-03-12 08:00 | Messekalender |
| 15 | 7 | Nachbereitung |  | 3h | 2007-03-19 08:00 | 2007-03-19 11:00 | 14 | 0d |  |  |  |

Notes:
- 14: am dritten Messetage von OB Ude / alle wichtigen Details bla bla bla
